# 1b - solution - Gantt chart

Schedule from MS Project, 2006-10-09 to 2006-11-08, status date 2006-10-11, A marks actual dates.
CMT

## Calendars

- 標準: Mon-Fri 08:00-12:00, 13:00-17:00; Sat-Sun off.

## Resources

| Resource | Group |
| --- | --- |
| A | programmer |
| B | programmer |
| C | programmer |
| SA | SA |
| PM | PM |

## Schedule

| ID | Task | Type | Duration | Start | Finish | Predecessors | Complete | Remaining | Baseline start | Baseline finish | Baseline duration | Total slack | Resources | Work | Actual work |
| --- | --- | --- | --- | --- | --- | --- | --- | --- | --- | --- | --- | --- | --- | --- | --- |
| 1 | project start | milestone | 0d | 2006-10-09 A | 2006-10-09 A |  | 100% |  | 2006-10-09 | 2006-10-09 | 0d |  |  |  |  |
| 2 | Requirements Analysis |  | 3d | 2006-10-12 A | 2006-10-16 A | 1 | 100% |  | 2006-10-09 | 2006-10-11 | 3d |  | SA [50%] | 12h | 12h |
| 3 | Develop test plan |  | 2d | 2006-10-09 A | 2006-10-10 A | 1 | 100% |  | 2006-10-09 | 2006-10-10 | 2d |  |  |  |  |
| 4 | Systems Design |  | 5d | 2006-10-17 | 2006-10-23 | 2 |  |  | 2006-10-12 | 2006-10-18 | 5d | 0d | SA; A [20%]; B | 72h |  |
| 5 | Write test drivers |  | 6d | 2006-10-11 A | 2006-10-18 | 3 | 17% | 5d | 2006-10-11 | 2006-10-18 | 6d | 7d | A; B; SA | 144h | 24h |
| 6 | Prepare test data |  | 2d | 2006-10-17 | 2006-10-18 | 2, 3 |  |  | 2006-10-12 | 2006-10-13 | 2d | 7d | PM [30%] | 4.8h |  |
| 7 | Code system |  | 4d | 2006-10-24 | 2006-10-27 | 4 |  |  | 2006-10-19 | 2006-10-24 | 4d | 0d |  |  |  |
| 8 | System test |  | 4d | 2006-10-30 | 2006-11-02 | 5, 6, 7 |  |  | 2006-10-25 | 2006-10-30 | 4d | 0d |  |  |  |
| 9 | Document system |  | 2d | 2006-10-24 | 2006-10-25 | 4 |  |  | 2006-10-19 | 2006-10-20 | 2d | 6d |  |  |  |
| 10 | Install |  | 4d | 2006-11-03 | 2006-11-08 | 8, 9 |  |  | 2006-10-31 | 2006-11-03 | 4d | 0d |  |  |  |
| 11 | project end | milestone | 0d | 2006-11-08 | 2006-11-08 | 10 |  |  | 2006-11-03 | 2006-11-03 | 0d | 0d |  |  |  |
